# BB-04 - kzst lijm-elementen

Schedule from MS Project, 2003-01-12 to 2003-01-31, status date 2003-01-08.
BAM Nelissen Van Egteren

## Calendars

- ALLEEN WERKDAGEN: Mon-Fri 08:30-12:30, 13:00-17:00; Sat-Sun off. Exceptions (off unless hours are given): 2003-01-11 to 2003-01-12 08:30-12:30, 13:00-17:00, 2003-01-18 to 2003-01-19 08:30-12:30, 13:00-17:00, 2003-01-25 to 2003-01-26 08:30-12:30, 13:00-17:00.

## Schedule

| ID | WBS | Task | Type | Duration | Start | Finish | Predecessors | Total slack |
| --- | --- | --- | --- | --- | --- | --- | --- | --- |
| 1 | 1 | **BOVENBOUWFASE** |  | 20d | 2003-01-12 | 2003-01-31 |  | 0d |
| 2 | 1.1 | kimmen op beg.grond metselen |  | 1d | 2003-01-12 | 2003-01-12 |  | 0d |
| 3 | 1.2 | beg.grond wanden lijmen |  | 3d | 2003-01-13 | 2003-01-15 | 2SS+1d | 0d |
| 4 | 1.3 | 1e verd.vloer breedplaat+stempels |  | 3d | 2003-01-16 | 2003-01-18 | 3SS+3d | 0d |
| 5 | 1.4 | 1e verd.vloer wapening+beton |  | 2d | 2003-01-18 | 2003-01-19 | 4SS+2d | 0d |
| 6 | 1.5 | kimmen op verd.vloer metselen |  | 1d | 2003-01-20 | 2003-01-20 | 5SS+2d | 0d |
| 7 | 1.6 | 1e verd. wanden lijmen |  | 3d | 2003-01-21 | 2003-01-23 | 6SS+1d | 0d |
| 8 | 1.7 | zoldervloer breedplaat+stempels |  | 3d | 2003-01-24 | 2003-01-26 | 7SS+3d | 0d |
| 9 | 1.8 | zoldervloer wapening+beton |  | 2d | 2003-01-26 | 2003-01-27 | 8SS+2d | 0d |
| 10 | 1.9 | kimmen op zoldervloer metselen |  | 1d | 2003-01-28 | 2003-01-28 | 9SS+2d | 0d |
| 11 | 1.10 | zolder wandtoppen lijmen |  | 3d | 2003-01-29 | 2003-01-31 | 10SS+1d | 0d |
| 12 | 1.11 | start gevel/dak fase | milestone | 0d | 2003-01-31 | 2003-01-31 | 11SS+3d | 0d |
